# DEFENSA RIBEREÑA RIO LARAMARCA

Schedule from Primavera P6, 2023-03-01 to 2024-01-24, data date 2023-03-01.
Must finish by 2024-01-31

## Calendars

- CALENDARIO P6: Mon-Sun 08:00-16:00. Exceptions (off unless hours are given): 2023-07-29 08:00-16:00, 2023-12-09 08:00-16:00.

## Schedule

| ID | WBS | Activity | Type | Duration | Start | Finish | Predecessors | Total float | Free float |
| --- | --- | --- | --- | --- | --- | --- | --- | --- | --- |
|  | C | **CONSTRUCCIÓN** |  |  | 2023-03-01 | 2024-01-24 |  |  |  |
|  | 70 | **OBRAS EXTERIORES** |  |  | 2023-03-01 | 2024-01-24 |  |  |  |
|  | 14 | **REFUERZO RIBERA DE RIO** |  |  | 2023-03-01 | 2024-01-24 |  |  |  |
|  | 0 | **INICIO** |  |  | 2023-03-01 | 2023-03-01 |  |  |  |
| A4350 |  | INICIO | milestone | 0d | 2023-03-01 | 2023-03-01 |  | 17.5d | 0d |
|  | 1 | **SUBPROYECTO A2 - INTERVENCIÓN AVENIDA PERÚ** |  |  | 2023-03-01 | 2023-08-10 |  |  |  |
|  | 1 | **OBRAS PRELIMINARES** |  |  | 2023-03-01 | 2023-05-10 |  |  |  |
| A1000 |  | UBICACIÓN Y DELIMITACIÓN DE LA ZONA DE PLANTACIÓN |  | 2d | 2023-03-01 | 2023-03-02 | A4350 SS | 17.5d | 0d |
| A01000 |  | MEJORAMIENTO DE SUELO CON TIERRA VEGETAL |  | 68d | 2023-03-02 | 2023-05-08 | A1000 SS+1d | 17.5d | 0d |
| A1010 |  | DESPEDREGADO DEL TERRENO CON MEDIOS MANUALES |  | 68d | 2023-03-03 | 2023-05-09 | A01000 SS+1d | 17.5d | 0d |
| A1020 |  | RASTRILLADO DEL TERRENO |  | 68d | 2023-03-04 | 2023-05-10 | A1010 SS+1d | 17.5d | 0d |
| A1030 |  | TRAZADO, MARCACIÓN Y ESTACADO |  | 68d | 2023-03-04 | 2023-05-10 | A1020 SS | 17.5d | 0d |
| A1040 |  | RETIRO Y ELIMINACIÓN DE RESIDUOS SÓLIDOS |  | 68d | 2023-03-04 | 2023-05-10 | A1010 SS+1d | 265d | 259d |
|  | 2 | **ADQUISICION DE PLANTONES (altura al adquirirse)** |  |  | 2023-03-19 | 2023-05-09 |  |  |  |
| A1100 |  | SENNA MULTIGLANDULOSA MUTUY (0.60 a 0.80m) |  | 26d | 2023-03-19 | 2023-04-13 | A1030 SS+15d | 17.5d | 0d |
| A1110 |  | ENCELIA CANESCEN GIRASOL SILVESTRE (0.20m a 0.30m) |  | 26d | 2023-03-19 | 2023-04-13 | A1100 SS | 17.5d | 0d |
| A1120 |  | WEDELIA TRIBOLATA WEDELIA (0.15m) |  | 26d | 2023-03-19 | 2023-04-13 | A1110 SS | 17.5d | 0d |
| A1050 |  | PROSOPIS PALLIDA KUNTH ALGARROBO (0.80 a 1.50m) |  | 26d | 2023-04-14 | 2023-05-09 | A1120 | 17.5d | 0d |
| A1060 |  | SCHINUS MOLLE MOLLE SERRANO (0.80 a 1.50m) |  | 26d | 2023-04-14 | 2023-05-09 | A1050 SS | 263d | 0d |
| A1070 |  | ACACIA MACRACANTHA FAIQUE (0.80 a 1.50m) |  | 26d | 2023-04-14 | 2023-05-09 | A1060 SS | 263d | 0d |
| A1080 |  | PARKINSONIA ACULEATA AZOTE DE CRISTO (1.00 a 1.50 m) |  | 26d | 2023-04-14 | 2023-05-09 | A1070 SS | 263d | 0d |
| A1090 |  | TESSARIA INTEGRIFOLIA RUIZ & PAV PAJARRO BOBO (0.80 a 1.50m) |  | 26d | 2023-04-14 | 2023-05-09 | A1080 SS | 263d | 0d |
|  | 3 | **ADQUISICION RECALCE (Se concidera el 5%)** |  |  | 2023-04-14 | 2023-05-10 |  |  |  |
| A1180 |  | SENNA MULTIGLANDULOSA MUTUY (0.60 a 0.80m) |  | 1d | 2023-04-14 | 2023-04-14 | A1100 | 291d | 0d |
| A1190 |  | ENCELIA CANESCEN GIRASOL SILVESTRE (0.20m a 0.30m) |  | 1d | 2023-04-14 | 2023-04-14 | A1180 SS | 291d | 0d |
| A1200 |  | WEDELIA TRIBOLATA WEDELIA (0.15m) |  | 1d | 2023-04-14 | 2023-04-14 | A1190 SS | 291d | 285d |
| A1130 |  | PROSOPIS PALLIDA KUNTH ALGARROBO (0.80 a 1.50m) |  | 1d | 2023-05-10 | 2023-05-10 | A1050 | 265d | 0d |
| A1140 |  | SCHINUS MOLLE MOLLE SERRANO (0.80 a 1.50m) |  | 1d | 2023-05-10 | 2023-05-10 | A1130 SS | 265d | 0d |
| A1150 |  | ACACIA MACRACANTHA FAIQUE (0.80 a 1.50m) |  | 1d | 2023-05-10 | 2023-05-10 | A1140 SS | 265d | 0d |
| A1160 |  | PARKINSONIA ACULEATA AZOTE DE CRISTO (1.00 a 1.50 m) |  | 1d | 2023-05-10 | 2023-05-10 | A1150 SS | 265d | 0d |
| A1170 |  | TESSARIA INTEGRIFOLIA RUIZ & PAV PAJARRO BOBO (0.80 a 1.50m) |  | 1d | 2023-05-10 | 2023-05-10 | A1160 SS | 265d | 259d |

| ID | WBS | Activity | Duration | Start | Finish | Predecessors | Total float | Free float |
| --- | --- | --- | --- | --- | --- | --- | --- | --- |
|  | 4 | **TRANSPORTE** |  | 2023-03-19 | 2023-05-10 |  |  |  |
| A1210 |  | Flete transporte terrestre para especies vegetales | 53d | 2023-03-19 | 2023-05-10 | A1100 SS | 265d | 259d |
|  | 5 | **ADQUISICION INSUMOS AGRICOLAS Y OTROS** |  | 2023-03-19 | 2023-05-10 |  |  |  |
| A1220 |  | COMPOST SACO 35kg | 53d | 2023-03-19 | 2023-05-10 | A1100 SS | 265d | 0d |
| A1230 |  | AZUFRE SACO 25kg | 53d | 2023-03-19 | 2023-05-10 | A1220 SS | 265d | 0d |
| A1240 |  | YESO SACO 40kg | 53d | 2023-03-19 | 2023-05-10 | A1230 SS | 265d | 0d |
| A1250 |  | NPK 10:30:10 SACO DE 50kg | 53d | 2023-03-19 | 2023-05-10 | A1240 SS | 265d | 0d |
| A1260 |  | NPK 20:20:20 SACO DE 50kg | 53d | 2023-03-19 | 2023-05-10 | A1250 SS | 265d | 0d |
| A1270 |  | TUTORES EUCALIPTO 2.5m | 53d | 2023-03-19 | 2023-05-10 | A1260 SS | 265d | 0d |
| A1280 |  | SOGA DE YUTE 5/64 DE 58m | 53d | 2023-03-19 | 2023-05-10 | A1270 SS | 265d | 0d |
| A1290 |  | PITON CONTRA INCENDIO PARA ADAPTACION DE MANGUERA DE CISTERNA | 3d | 2023-03-19 | 2023-03-21 | A1280 SS | 315d | 309d |
|  | 6 | **INSTALACION DE PLANTONES (Incluye colocacion de sustrato, tierra del lugar,** |  | 2023-03-20 | 2023-05-12 |  |  |  |
| A1350 |  | SENNA MULTIGLANDULOSA MUTUY (0.60 a 0.80m) | 28d | 2023-03-20 | 2023-04-16 | A1100 SS+1d | 289d | 283d |
| A1360 |  | ENCELIA CANESCEN GIRASOL SILVESTRE (0.20m a 0.30m) | 28d | 2023-03-20 | 2023-04-16 | A1110 SS+1d | 289d | 283d |
| A1370 |  | WEDELIA TRIBOLATA WEDELIA (0.15m) | 28d | 2023-03-20 | 2023-04-16 | A1120 SS+1d | 289d | 283d |
| A1300 |  | PROSOPIS PALLIDA KUNTH ALGARROBO (0.80 a 1.50m) | 28d | 2023-04-15 | 2023-05-12 | A1050 SS+1d | 17.5d | 0d |
| A1310 |  | SCHINUS MOLLE MOLLE SERRANO (0.80 a 1.50m) | 28d | 2023-04-15 | 2023-05-12 | A1060 SS+1d | 263d | 257d |
| A1320 |  | ACACIA MACRACANTHA FAIQUE (0.80 a 1.50m) | 28d | 2023-04-15 | 2023-05-12 | A1070 SS+1d | 263d | 257d |
| A1330 |  | PARKINSONIA ACULEATA AZOTE DE CRISTO (1.00 a 1.50 m) | 28d | 2023-04-15 | 2023-05-12 | A1080 SS+1d | 263d | 257d |
| A1340 |  | TESSARIA INTEGRIFOLIA RUIZ & PAV PAJARRO BOBO (0.80 a 1.50m) | 28d | 2023-04-15 | 2023-05-12 | A1090 SS+1d | 263d | 257d |
|  | 7 | **NSTALACIÓN DE ALCORQUES** |  | 2023-04-15 | 2023-05-12 |  |  |  |
| A1380 |  | ALCORQUES DE PIEDRA DE CANTO RODADO PARA ARBOLES | 27.25d | 2023-04-15 | 2023-05-12 | A1300 SS | 17.5d | 0d |
|  | 8 | **RIEGO DE ESPECIES 12 MESES ( instalacion+establecimiento)** |  | 2023-05-13 | 2023-08-10 |  |  |  |
| A1390 |  | Riego por inundación, mediante camión cisterna con mangera adaptada con piton | 90d | 2023-05-13 | 2023-08-10 | A1300 | 173d | 0d |

| ID | WBS | Activity | Duration | Start | Finish | Predecessors | Total float | Free float |
| --- | --- | --- | --- | --- | --- | --- | --- | --- |
|  | 9 | **MANTENIMIENTO PREVENTIVO PARA ESTABLECIMIENTO DE ESPECIE (12** |  | 2023-05-13 | 2023-08-10 |  |  |  |
| A1400 |  | MANO DE OBRA + PODA + REMOCION, DESMALEZADO, RECALCE Y | 90d | 2023-05-13 | 2023-08-10 | A1390 SS | 173d | 167d |
|  | 2 | **SUBPROYECTO A2 - RAMPA DURA** |  | 2023-05-12 | 2023-10-22 |  |  |  |
|  | 1 | **OBRAS PRELIMINARES** |  | 2023-05-12 | 2023-07-22 |  |  |  |
| A3100 |  | UBICACIÓN Y DELIMITACIÓN DE LA ZONA DE PLANTACIÓN | 2d | 2023-05-12 | 2023-05-14 | A1380 | 17.5d | 0d |
| A3090 |  | MEJORAMIENTO DE SUELO CON TIERRA VEGETAL | 68d | 2023-05-13 | 2023-07-20 | A3100 SS+1d | 17.5d | 0d |
| A3110 |  | DESPEDREGADO DEL TERRENO CON MEDIOS MANUALES | 68d | 2023-05-14 | 2023-07-21 | A3090 SS+1d | 17.5d | 0d |
| A3120 |  | RASTRILLADO DEL TERRENO | 68d | 2023-05-15 | 2023-07-22 | A3110 SS+1d | 17.5d | 0d |
| A3130 |  | TRAZADO, MARCACIÓN Y ESTACADO | 68d | 2023-05-15 | 2023-07-22 | A3120 SS | 17.5d | 0d |
| A3140 |  | RETIRO Y ELIMINACIÓN DE RESIDUOS SÓLIDOS | 68d | 2023-05-15 | 2023-07-22 | A3110 SS+1d | 192.75d | 186.75d |
|  | 2 | **ADQUISICION DE PLANTONES (altura al adquirirse)** |  | 2023-05-30 | 2023-07-21 |  |  |  |
| A3200 |  | SENNA MULTIGLANDULOSA MUTUY (0.60 a 0.80m) | 26d | 2023-05-30 | 2023-06-25 | A3130 SS+15d | 17.5d | 0d |
| A3210 |  | ENCELIA CANESCEN GIRASOL SILVESTRE (0.20m a 0.30m) | 26d | 2023-05-30 | 2023-06-25 | A3200 SS | 17.5d | 0d |
| A3220 |  | WEDELIA TRIBOLATA WEDELIA (0.15m) | 26d | 2023-05-30 | 2023-06-25 | A3210 SS | 17.5d | 0d |
| A3150 |  | PROSOPIS PALLIDA KUNTH ALGARROBO (0.80 a 1.50m) | 26d | 2023-06-25 | 2023-07-21 | A3220 | 17.5d | 0d |
| A3160 |  | SCHINUS MOLLE MOLLE SERRANO (0.80 a 1.50m) | 26d | 2023-06-25 | 2023-07-21 | A3150 SS | 190.75d | 0d |
| A3170 |  | ACACIA MACRACANTHA FAIQUE (0.80 a 1.50m) | 26d | 2023-06-25 | 2023-07-21 | A3160 SS | 190.75d | 0d |
| A3180 |  | PARKINSONIA ACULEATA AZOTE DE CRISTO (1.00 a 1.50 m) | 26d | 2023-06-25 | 2023-07-21 | A3170 SS | 190.75d | 0d |
| A3190 |  | TESSARIA INTEGRIFOLIA RUIZ & PAV PAJARRO BOBO (0.80 a 1.50m) | 26d | 2023-06-25 | 2023-07-21 | A3180 SS | 190.75d | 0d |
|  | 3 | **ADQUISICION RECALCE (Se concidera el 5%)** |  | 2023-06-25 | 2023-07-22 |  |  |  |
| A3280 |  | SENNA MULTIGLANDULOSA MUTUY (0.60 a 0.80m) | 1d | 2023-06-25 | 2023-06-26 | A3200 | 218.75d | 0d |
| A3290 |  | ENCELIA CANESCEN GIRASOL SILVESTRE (0.20m a 0.30m) | 1d | 2023-06-25 | 2023-06-26 | A3280 SS | 218.75d | 0d |
| A3300 |  | WEDELIA TRIBOLATA WEDELIA (0.15m) | 1d | 2023-06-25 | 2023-06-26 | A3290 SS | 218.75d | 212.75d |
| A3230 |  | PROSOPIS PALLIDA KUNTH ALGARROBO (0.80 a 1.50m) | 1d | 2023-07-21 | 2023-07-22 | A3150 | 192.75d | 0d |
| A3240 |  | SCHINUS MOLLE MOLLE SERRANO (0.80 a 1.50m) | 1d | 2023-07-21 | 2023-07-22 | A3230 SS | 192.75d | 0d |
| A3250 |  | ACACIA MACRACANTHA FAIQUE (0.80 a 1.50m) | 1d | 2023-07-21 | 2023-07-22 | A3240 SS | 192.75d | 0d |
| A3260 |  | PARKINSONIA ACULEATA AZOTE DE CRISTO (1.00 a 1.50 m) | 1d | 2023-07-21 | 2023-07-22 | A3250 SS | 192.75d | 0d |
| A3270 |  | TESSARIA INTEGRIFOLIA RUIZ & PAV PAJARRO BOBO (0.80 a 1.50m) | 1d | 2023-07-21 | 2023-07-22 | A3260 SS | 192.75d | 186.75d |

| ID | WBS | Activity | Duration | Start | Finish | Predecessors | Total float | Free float |
| --- | --- | --- | --- | --- | --- | --- | --- | --- |
|  | 4 | **TRANSPORTE** |  | 2023-05-30 | 2023-07-22 |  |  |  |
| A3310 |  | Flete transporte terrestre para especies vegetales | 53d | 2023-05-30 | 2023-07-22 | A3200 SS | 192.75d | 186.75d |
|  | 5 | **ADQUISICION INSUMOS AGRICOLAS Y OTROS** |  | 2023-05-30 | 2023-07-22 |  |  |  |
| A3320 |  | COMPOST SACO 35kg | 53d | 2023-05-30 | 2023-07-22 | A3200 SS | 192.75d | 0d |
| A3330 |  | AZUFRE SACO 25kg | 53d | 2023-05-30 | 2023-07-22 | A3320 SS | 192.75d | 0d |
| A3340 |  | YESO SACO 40kg | 53d | 2023-05-30 | 2023-07-22 | A3330 SS | 192.75d | 0d |
| A3350 |  | NPK 10:30:10 SACO DE 50kg | 53d | 2023-05-30 | 2023-07-22 | A3340 SS | 192.75d | 0d |
| A3360 |  | NPK 20:20:20 SACO DE 50kg | 53d | 2023-05-30 | 2023-07-22 | A3350 SS | 192.75d | 0d |
| A3370 |  | TUTORES EUCALIPTO 2.5m | 53d | 2023-05-30 | 2023-07-22 | A3360 SS | 192.75d | 0d |
| A3380 |  | SOGA DE YUTE 5/64 DE 58m | 53d | 2023-05-30 | 2023-07-22 | A3370 SS | 192.75d | 0d |
| A3390 |  | PITON CONTRA INCENDIO PARA ADAPTACION DE MANGUERA DE CISTERNA | 3d | 2023-05-30 | 2023-06-02 | A3380 SS | 242.75d | 236.75d |
|  | 6 | **INSTALACION DE PLANTONES (Incluye colocacion de sustrato, tierra del lugar,** |  | 2023-05-31 | 2023-07-24 |  |  |  |
| A3450 |  | SENNA MULTIGLANDULOSA MUTUY (0.60 a 0.80m) | 28d | 2023-05-31 | 2023-06-28 | A3200 SS+1d | 216.75d | 210.75d |
| A3460 |  | ENCELIA CANESCEN GIRASOL SILVESTRE (0.20m a 0.30m) | 28d | 2023-05-31 | 2023-06-28 | A3210 SS+1d | 216.75d | 210.75d |
| A3470 |  | WEDELIA TRIBOLATA WEDELIA (0.15m) | 28d | 2023-05-31 | 2023-06-28 | A3220 SS+1d | 216.75d | 210.75d |
| A3400 |  | PROSOPIS PALLIDA KUNTH ALGARROBO (0.80 a 1.50m) | 28d | 2023-06-26 | 2023-07-24 | A3150 SS+1d | 17.5d | 0d |
| A3410 |  | SCHINUS MOLLE MOLLE SERRANO (0.80 a 1.50m) | 28d | 2023-06-26 | 2023-07-24 | A3160 SS+1d | 190.75d | 184.75d |
| A3420 |  | ACACIA MACRACANTHA FAIQUE (0.80 a 1.50m) | 28d | 2023-06-26 | 2023-07-24 | A3170 SS+1d | 190.75d | 184.75d |
| A3430 |  | PARKINSONIA ACULEATA AZOTE DE CRISTO (1.00 a 1.50 m) | 28d | 2023-06-26 | 2023-07-24 | A3180 SS+1d | 190.75d | 184.75d |
| A3440 |  | TESSARIA INTEGRIFOLIA RUIZ & PAV PAJARRO BOBO (0.80 a 1.50m) | 28d | 2023-06-26 | 2023-07-24 | A3190 SS+1d | 190.75d | 184.75d |
|  | 7 | **NSTALACIÓN DE ALCORQUES** |  | 2023-06-26 | 2023-07-23 |  |  |  |
| A3480 |  | ALCORQUES DE PIEDRA DE CANTO RODADO PARA ARBOLES | 27.25d | 2023-06-26 | 2023-07-23 | A3400 SS | 17.5d | 0d |
|  | 8 | **RIEGO DE ESPECIES 12 MESES ( instalacion+establecimiento)** |  | 2023-07-24 | 2023-10-22 |  |  |  |
| A3490 |  | Riego por inundación, mediante camión cisterna con mangera adaptada con piton | 90d | 2023-07-24 | 2023-10-22 | A3400 | 100.75d | 0d |

| ID | WBS | Activity | Duration | Start | Finish | Predecessors | Total float | Free float |
| --- | --- | --- | --- | --- | --- | --- | --- | --- |
|  | 9 | **MANTENIMIENTO PREVENTIVO PARA ESTABLECIMIENTO DE ESPECIE (12** |  | 2023-07-24 | 2023-10-22 |  |  |  |
| A3500 |  | MANO DE OBRA + PODA + REMOCION, DESMALEZADO, RECALCE Y | 90d | 2023-07-24 | 2023-10-22 | A3490 SS | 100.75d | 94.75d |
|  | 3 | **SUBPROYECTO A2 - TANGAY** |  | 2023-07-23 | 2023-11-01 |  |  |  |
|  | 1 | **OBRAS PRELIMINARES** |  | 2023-07-23 | 2023-07-31 |  |  |  |
| A3930 |  | MEJORAMIENTO DE SUELO CON TIERRA VEGETAL | 7d | 2023-07-23 | 2023-07-30 | A3940 SS | 17.5d | 0d |
| A3940 |  | UBICACIÓN Y DELIMITACIÓN DE LA ZONA DE PLANTACIÓN | 1d | 2023-07-23 | 2023-07-24 | A3480 | 17.5d | 0d |
| A3950 |  | DESPEDREGADO DEL TERRENO CON MEDIOS MANUALES | 7d | 2023-07-23 | 2023-07-30 | A3930 SS | 17.5d | 0d |
| A3960 |  | RASTRILLADO DEL TERRENO | 7d | 2023-07-23 | 2023-07-30 | A3950 SS | 17.5d | 0d |
| A3970 |  | TRAZADO, MARCACIÓN Y ESTACADO | 7d | 2023-07-23 | 2023-07-30 | A3960 SS | 17.5d | 0d |
| A3980 |  | RETIRO Y ELIMINACIÓN DE RESIDUOS SÓLIDOS | 7d | 2023-07-24 | 2023-07-31 | A3950 SS+1d | 183.5d | 177.5d |
|  | 2 | **ADQUISICION DE PLANTONES (altura al adquirirse)** |  | 2023-07-25 | 2023-08-02 |  |  |  |
| A4040 |  | SENNA MULTIGLANDULOSA MUTUY (0.60 a 0.80m) | 4d | 2023-07-25 | 2023-07-29 | A3970 SS+2d | 17.5d | 0d |
| A4050 |  | ENCELIA CANESCEN GIRASOL SILVESTRE (0.20m a 0.30m) | 4d | 2023-07-25 | 2023-07-29 | A4040 SS | 17.5d | 0d |
| A4060 |  | WEDELIA TRIBOLATA WEDELIA (0.15m) | 4d | 2023-07-25 | 2023-07-29 | A4050 SS | 17.5d | 0d |
| A3990 |  | PROSOPIS PALLIDA KUNTH ALGARROBO (0.80 a 1.50m) | 4d | 2023-07-29 | 2023-08-02 | A4060 | 17.5d | 0d |
| A4000 |  | SCHINUS MOLLE MOLLE SERRANO (0.80 a 1.50m) | 4d | 2023-07-29 | 2023-08-02 | A3990 SS | 180.5d | 0d |
| A4010 |  | ACACIA MACRACANTHA FAIQUE (0.80 a 1.50m) | 4d | 2023-07-29 | 2023-08-02 | A4000 SS | 180.5d | 0d |
| A4020 |  | PARKINSONIA ACULEATA AZOTE DE CRISTO (1.00 a 1.50 m) | 4d | 2023-07-29 | 2023-08-02 | A4010 SS | 180.5d | 0d |
| A4030 |  | TESSARIA INTEGRIFOLIA RUIZ & PAV PAJARRO BOBO (0.80 a 1.50m) | 4d | 2023-07-29 | 2023-08-02 | A4020 SS | 180.5d | 0d |
|  | 3 | **ADQUISICION RECALCE (Se concidera el 5%)** |  | 2023-07-29 | 2023-08-03 |  |  |  |
| A4120 |  | SENNA MULTIGLANDULOSA MUTUY (0.60 a 0.80m) | 1d | 2023-07-29 | 2023-07-30 | A4040 | 184.5d | 0d |
| A4130 |  | ENCELIA CANESCEN GIRASOL SILVESTRE (0.20m a 0.30m) | 1d | 2023-07-29 | 2023-07-30 | A4120 SS | 184.5d | 0d |
| A4140 |  | WEDELIA TRIBOLATA WEDELIA (0.15m) | 1d | 2023-07-29 | 2023-07-30 | A4130 SS | 184.5d | 178.5d |
| A4070 |  | PROSOPIS PALLIDA KUNTH ALGARROBO (0.80 a 1.50m) | 1d | 2023-08-02 | 2023-08-03 | A3990 | 180.5d | 0d |
| A4080 |  | SCHINUS MOLLE MOLLE SERRANO (0.80 a 1.50m) | 1d | 2023-08-02 | 2023-08-03 | A4070 SS | 180.5d | 0d |
| A4090 |  | ACACIA MACRACANTHA FAIQUE (0.80 a 1.50m) | 1d | 2023-08-02 | 2023-08-03 | A4080 SS | 180.5d | 0d |
| A4100 |  | PARKINSONIA ACULEATA AZOTE DE CRISTO (1.00 a 1.50 m) | 1d | 2023-08-02 | 2023-08-03 | A4090 SS | 180.5d | 0d |
| A4110 |  | TESSARIA INTEGRIFOLIA RUIZ & PAV PAJARRO BOBO (0.80 a 1.50m) | 1d | 2023-08-02 | 2023-08-03 | A4100 SS | 180.5d | 174.5d |

| ID | WBS | Activity | Duration | Start | Finish | Predecessors | Total float | Free float |
| --- | --- | --- | --- | --- | --- | --- | --- | --- |
|  | 4 | **TRANSPORTE** |  | 2023-07-25 | 2023-08-03 |  |  |  |
| A4150 |  | Flete transporte terrestre para especies vegetales | 9d | 2023-07-25 | 2023-08-03 | A4040 SS | 180.5d | 174.5d |
|  | 5 | **ADQUISICION INSUMOS AGRICOLAS Y OTROS** |  | 2023-07-25 | 2023-08-03 |  |  |  |
| A4160 |  | COMPOST SACO 35kg | 9d | 2023-07-25 | 2023-08-03 | A4040 SS | 180.5d | 0d |
| A4170 |  | AZUFRE SACO 25kg | 9d | 2023-07-25 | 2023-08-03 | A4160 SS | 180.5d | 0d |
| A4180 |  | YESO SACO 40kg | 9d | 2023-07-25 | 2023-08-03 | A4170 SS | 180.5d | 0d |
| A4190 |  | NPK 10:30:10 SACO DE 50kg | 9d | 2023-07-25 | 2023-08-03 | A4180 SS | 180.5d | 0d |
| A4200 |  | NPK 20:20:20 SACO DE 50kg | 9d | 2023-07-25 | 2023-08-03 | A4190 SS | 180.5d | 0d |
| A4210 |  | TUTORES EUCALIPTO 2.5m | 9d | 2023-07-25 | 2023-08-03 | A4200 SS | 180.5d | 0d |
| A4220 |  | SOGA DE YUTE 5/64 DE 58m | 9d | 2023-07-25 | 2023-08-03 | A4210 SS | 180.5d | 0d |
| A4230 |  | PITON CONTRA INCENDIO PARA ADAPTACION DE MANGUERA DE CISTERNA | 9d | 2023-07-25 | 2023-08-03 | A4220 SS | 180.5d | 174.5d |
|  | 6 | **INSTALACION DE PLANTONES (Incluye colocacion de sustrato, tierra del lugar,** |  | 2023-07-26 | 2023-08-03 |  |  |  |
| A4290 |  | SENNA MULTIGLANDULOSA MUTUY (0.60 a 0.80m) | 4d | 2023-07-26 | 2023-07-30 | A4040 SS+1d | 184.5d | 178.5d |
| A4300 |  | ENCELIA CANESCEN GIRASOL SILVESTRE (0.20m a 0.30m) | 4d | 2023-07-26 | 2023-07-30 | A4050 SS+1d | 184.5d | 178.5d |
| A4310 |  | WEDELIA TRIBOLATA WEDELIA (0.15m) | 4d | 2023-07-26 | 2023-07-30 | A4060 SS+1d | 184.5d | 178.5d |
| A4240 |  | PROSOPIS PALLIDA KUNTH ALGARROBO (0.80 a 1.50m) | 4d | 2023-07-30 | 2023-08-03 | A3990 SS+1d | 17.5d | 0d |
| A4250 |  | SCHINUS MOLLE MOLLE SERRANO (0.80 a 1.50m) | 4d | 2023-07-30 | 2023-08-03 | A4000 SS+1d | 180.5d | 174.5d |
| A4260 |  | ACACIA MACRACANTHA FAIQUE (0.80 a 1.50m) | 4d | 2023-07-30 | 2023-08-03 | A4010 SS+1d | 180.5d | 174.5d |
| A4270 |  | PARKINSONIA ACULEATA AZOTE DE CRISTO (1.00 a 1.50 m) | 4d | 2023-07-30 | 2023-08-03 | A4020 SS+1d | 180.5d | 174.5d |
| A4280 |  | TESSARIA INTEGRIFOLIA RUIZ & PAV PAJARRO BOBO (0.80 a 1.50m) | 4d | 2023-07-30 | 2023-08-03 | A4030 SS+1d | 180.5d | 174.5d |
|  | 7 | **NSTALACIÓN DE ALCORQUES** |  | 2023-07-30 | 2023-08-03 |  |  |  |
| A4320 |  | ALCORQUES DE PIEDRA DE CANTO RODADO PARA ARBOLES | 4d | 2023-07-30 | 2023-08-03 | A4240 SS | 17.5d | 0d |
|  | 8 | **RIEGO DE ESPECIES 12 MESES ( instalacion+establecimiento)** |  | 2023-08-03 | 2023-11-01 |  |  |  |
| A4330 |  | Riego por inundación, mediante camión cisterna con mangera adaptada con piton | 90d | 2023-08-03 | 2023-11-01 | A4240 | 90.5d | 0d |

| ID | WBS | Activity | Duration | Start | Finish | Predecessors | Total float | Free float |
| --- | --- | --- | --- | --- | --- | --- | --- | --- |
|  | 9 | **MANTENIMIENTO PREVENTIVO PARA ESTABLECIMIENTO DE ESPECIE (12** |  | 2023-08-03 | 2023-11-01 |  |  |  |
| A4340 |  | MANO DE OBRA + PODA + REMOCION, DESMALEZADO, RECALCE Y | 90d | 2023-08-03 | 2023-11-01 | A4330 SS | 90.5d | 84.5d |
|  | 4 | **SUBPROYECTO A1 - HUMEDAL VILLA MARIA MARGEN IZQUIERDO** |  | 2023-03-01 | 2024-01-24 |  |  |  |
|  | 1 | **OBRAS PRELIMINARES** |  | 2023-03-01 | 2023-10-16 |  |  |  |
| A2020 |  | UBICACIÓN Y DELIMITACIÓN DE LA ZONA DE PLANTACIÓN | 6.5d | 2023-03-01 | 2023-03-07 |  | 6d | 0d |
| A2010 |  | MEJORAMIENTO DE SUELO CON TIERRA VEGETAL | 220d | 2023-03-04 | 2023-10-09 | A2020 SS+3d | 6d | 0d |
| A2030 |  | DESPEDREGADO DEL TERRENO CON MEDIOS MANUALES | 220d | 2023-03-07 | 2023-10-12 | A2010 SS+3d | 6d | 0d |
| A2040 |  | RASTRILLADO DEL TERRENO | 220d | 2023-03-10 | 2023-10-15 | A2030 SS+3d | 6d | 0d |
| A2060 |  | RETIRO Y ELIMINACIÓN DE RESIDUOS SÓLIDOS | 220d | 2023-03-10 | 2023-10-15 | A2030 SS+3d | 107d | 101d |
| A2050 |  | TRAZADO, MARCACIÓN Y ESTACADO | 220d | 2023-03-11 | 2023-10-16 | A2040 SS+1d | 6d | 0d |
|  | 2 | **ADQUISICION DE PLANTONES (altura al adquirirse)** |  | 2023-05-01 | 2023-10-17 |  |  |  |
| A2640 |  | BATIS MARITIMA VIDRIO (H:0.15m) | 85d | 2023-05-01 | 2023-07-24 | A2050 SS+51d | 6d | 0d |
| A2650 |  | ENCELIA CANESCEN GIRASOL SILVESTRE (0.20m a 0.30m) | 85d | 2023-05-01 | 2023-07-24 | A2640 SS | 6d | 0d |
| A2660 |  | PHYLA NODIFLORA LIPPIA (h:0.15m) | 85d | 2023-05-01 | 2023-07-24 | A2650 SS | 6d | 0d |
| A2670 |  | SESUVIUM PORTULACASTRUM PORTULACA (h:0.15m) | 85d | 2023-05-01 | 2023-07-24 | A2660 SS | 6d | 0d |
| A2680 |  | SCIRPUS CALIFORNICUS ENEA (h:0.50m) | 85d | 2023-05-01 | 2023-07-24 | A2670 SS | 6d | 0d |
| A2690 |  | SCIRPUS CONGLOMERATUS JUNCO (h:0.50m) | 85d | 2023-05-01 | 2023-07-24 | A2680 SS | 6d | 0d |
| A2700 |  | PASPALUM VAGINATUM GRAMA DE AGUA (h:0.15m) | 85d | 2023-05-01 | 2023-07-24 | A2690 SS | 6d | 0d |
| A2580 |  | PROSOPIS PALLIDA KUNTH ALGARROBO (0.80 a 1.50m) | 85d | 2023-07-25 | 2023-10-17 | A2700 | 6d | 0d |
| A2590 |  | SCHINUS MOLLE MOLLE SERRANO (0.80 a 1.50m) | 85d | 2023-07-25 | 2023-10-17 | A2580 SS | 6d | 0d |
| A2600 |  | ACACIA MACRACANTHA FAIQUE (0.80 a 1.50m) | 85d | 2023-07-25 | 2023-10-17 | A2590 SS | 6d | 0d |
| A2610 |  | PARKINSONIA ACULEATA AZOTE DE CRISTO (1.00 a 1.50 m) | 85d | 2023-07-25 | 2023-10-17 | A2600 SS | 6d | 0d |
| A2620 |  | TESSARIA INTEGRIFOLIA RUIZ & PAV PAJARRO BOBO (0.80 a 1.50m) | 85d | 2023-07-25 | 2023-10-17 | A2610 SS | 6d | 0d |
| A2630 |  | BACCHARIS SALICIFOLIA CHILCA (h:080 a 1.50m) | 85d | 2023-07-25 | 2023-10-17 | A2620 SS | 6d | 0d |

| ID | WBS | Activity | Duration | Start | Finish | Predecessors | Total float | Free float |
| --- | --- | --- | --- | --- | --- | --- | --- | --- |
|  | 3 | **ADQUISICION RECALCE (Se concidera el 5%)** |  | 2023-07-25 | 2023-10-22 |  |  |  |
| A2770 |  | BATIS MARITIMA VIDRIO (H:0.15m) | 5d | 2023-07-25 | 2023-07-29 | A2640 | 185d | 179d |
| A2780 |  | ENCELIA CANESCEN GIRASOL SILVESTRE (0.20m a 0.30m) | 5d | 2023-07-25 | 2023-07-29 | A2650 | 185d | 179d |
| A2790 |  | PHYLA NODIFLORA LIPPIA (h:0.15m) | 5d | 2023-07-25 | 2023-07-29 | A2660 | 185d | 179d |
| A2800 |  | SESUVIUM PORTULACASTRUM PORTULACA (h:0.15m) | 5d | 2023-07-25 | 2023-07-29 | A2670 | 185d | 179d |
| A2810 |  | SCIRPUS CALIFORNICUS ENEA (h:0.50m) | 5d | 2023-07-25 | 2023-07-29 | A2680 | 185d | 179d |
| A2820 |  | SCIRPUS CONGLOMERATUS JUNCO (h:0.50m) | 5d | 2023-07-25 | 2023-07-29 | A2690 | 185d | 179d |
| A2830 |  | PASPALUM VAGINATUM GRAMA DE AGUA (h:0.15m) | 5d | 2023-07-25 | 2023-07-29 | A2700 | 185d | 179d |
| A2710 |  | PROSOPIS PALLIDA KUNTH ALGARROBO (0.80 a 1.50m) | 5d | 2023-10-18 | 2023-10-22 | A2580 | 100d | 94d |
| A2720 |  | SCHINUS MOLLE MOLLE SERRANO (0.80 a 1.50m) | 5d | 2023-10-18 | 2023-10-22 | A2590 | 100d | 94d |
| A2730 |  | ACACIA MACRACANTHA FAIQUE (0.80 a 1.50m) | 5d | 2023-10-18 | 2023-10-22 | A2600 | 100d | 94d |
| A2740 |  | PARKINSONIA ACULEATA AZOTE DE CRISTO (1.00 a 1.50 m) | 5d | 2023-10-18 | 2023-10-22 | A2610 | 100d | 94d |
| A2750 |  | TESSARIA INTEGRIFOLIA RUIZ & PAV PAJARRO BOBO (0.80 a 1.50m) | 5d | 2023-10-18 | 2023-10-22 | A2620 | 100d | 94d |
| A2760 |  | BACCHARIS SALICIFOLIA CHILCA (h:080 a 1.50m) | 5d | 2023-10-18 | 2023-10-22 | A2630 | 100d | 94d |
|  | 4 | **TRANSPORTE** |  | 2023-05-01 | 2023-10-22 |  |  |  |
| A2840 |  | Flete transporte terrestre para especies vegetales | 175d | 2023-05-01 | 2023-10-22 | A2640 SS | 100d | 94d |
|  | 5 | **ADQUISICION INSUMOS AGRICOLAS Y OTROS** |  | 2023-05-01 | 2023-10-22 |  |  |  |
| A2850 |  | COMPOST SACO 35kg | 175d | 2023-05-01 | 2023-10-22 | A2640 SS | 100d | 0d |
| A2860 |  | AZUFRE SACO 25kg | 175d | 2023-05-01 | 2023-10-22 | A2850 SS | 100d | 0d |
| A2870 |  | YESO SACO 40kg | 175d | 2023-05-01 | 2023-10-22 | A2860 SS | 100d | 0d |
| A2880 |  | NPK 10:30:10 SACO DE 50kg | 175d | 2023-05-01 | 2023-10-22 | A2870 SS | 100d | 0d |
| A2890 |  | NPK 20:20:20 SACO DE 50kg | 175d | 2023-05-01 | 2023-10-22 | A2880 SS | 100d | 0d |
| A2900 |  | TUTORES EUCALIPTO 2.5m | 175d | 2023-05-01 | 2023-10-22 | A2890 SS | 100d | 0d |
| A2910 |  | SOGA DE YUTE 5/64 DE 58m | 175d | 2023-05-01 | 2023-10-22 | A2900 SS | 100d | 0d |
| A2920 |  | PITON CONTRA INCENDIO PARA ADAPTACION DE MANGUERA DE CISTERNA | 3d | 2023-05-01 | 2023-05-03 | A2910 SS | 272d | 266d |

| ID | WBS | Activity | Duration | Start | Finish | Predecessors | Total float | Free float | Constraint |
| --- | --- | --- | --- | --- | --- | --- | --- | --- | --- |
|  | 6 | **INSTALACION DE PLANTONES (Incluye colocacion de sustrato, tierra del lugar,** |  | 2023-05-01 | 2023-10-26 |  |  |  |  |
| A2990 |  | BATIS MARITIMA VIDRIO (H:0.15m) | 90d | 2023-05-01 | 2023-07-29 | A2640 SS | 185d | 179d | start on or after 2023-05-01 |
| A3000 |  | ENCELIA CANESCEN GIRASOL SILVESTRE (0.20m a 0.30m) | 90d | 2023-05-01 | 2023-07-29 | A2650 SS | 185d | 179d |  |
| A3010 |  | PHYLA NODIFLORA LIPPIA (h:0.15m) | 90d | 2023-05-01 | 2023-07-29 | A2660 SS | 185d | 179d |  |
| A3020 |  | SESUVIUM PORTULACASTRUM PORTULACA (h:0.15m) | 90d | 2023-05-01 | 2023-07-29 | A2670 SS | 185d | 179d |  |
| A3030 |  | SCIRPUS CALIFORNICUS ENEA (h:0.50m) | 90d | 2023-05-01 | 2023-07-29 | A2680 SS | 185d | 179d |  |
| A3040 |  | SCIRPUS CONGLOMERATUS JUNCO (h:0.50m) | 90d | 2023-05-01 | 2023-07-29 | A2690 SS | 185d | 179d |  |
| A3050 |  | PASPALUM VAGINATUM GRAMA DE AGUA (h:0.15m) | 90d | 2023-05-01 | 2023-07-29 | A2700 SS | 185d | 179d |  |
| A2930 |  | PROSOPIS PALLIDA KUNTH ALGARROBO (0.80 a 1.50m) | 90d | 2023-07-29 | 2023-10-26 | A2580 SS+4d | 96d | 0d |  |
| A2940 |  | SCHINUS MOLLE MOLLE SERRANO (0.80 a 1.50m) | 90d | 2023-07-29 | 2023-10-26 | A2590 SS+4d | 96d | 90d |  |
| A2950 |  | ACACIA MACRACANTHA FAIQUE (0.80 a 1.50m) | 90d | 2023-07-29 | 2023-10-26 | A2600 SS+4d | 96d | 90d |  |
| A2960 |  | PARKINSONIA ACULEATA AZOTE DE CRISTO (1.00 a 1.50 m) | 90d | 2023-07-29 | 2023-10-26 | A2610 SS+4d | 96d | 90d |  |
| A2970 |  | TESSARIA INTEGRIFOLIA RUIZ & PAV PAJARRO BOBO (0.80 a 1.50m) | 90d | 2023-07-29 | 2023-10-26 | A2620 SS+4d | 96d | 90d |  |
| A2980 |  | BACCHARIS SALICIFOLIA CHILCA (h:080 a 1.50m) | 90d | 2023-07-29 | 2023-10-26 | A2630 SS+4d | 6d | 0d |  |
|  | 7 | **NSTALACIÓN DE ALCORQUES** |  | 2023-07-29 | 2023-10-26 |  |  |  |  |
| A3060 |  | ALCORQUES DE PIEDRA DE CANTO RODADO PARA ARBOLES | 90d | 2023-07-29 | 2023-10-26 | A2930 SS | 96d | 90d |  |
|  | 8 | **RIEGO DE ESPECIES 12 MESES ( instalacion+establecimiento)** |  | 2023-10-27 | 2024-01-24 |  |  |  |  |
| A3070 |  | Riego por inundación, mediante camión cisterna con mangera adaptada con piton | 90d | 2023-10-27 | 2024-01-24 | A2980 | 6d | 0d |  |
|  | 9 | **MANTENIMIENTO PREVENTIVO PARA ESTABLECIMIENTO DE ESPECIE (12** |  | 2023-10-27 | 2024-01-24 |  |  |  |  |
| A3080 |  | MANO DE OBRA + PODA + REMOCION, DESMALEZADO, RECALCE Y | 90d | 2023-10-27 | 2024-01-24 | A3070 SS | 6d | 0d |  |
|  | 5 | **SUBPROYECTO A1 - HUMEDAL VILLA MARIA MARGEN DERECHO** |  | 2023-03-01 | 2024-01-24 |  |  |  |  |
|  | 1 | **OBRAS PRELIMINARES** |  | 2023-03-01 | 2023-10-16 |  |  |  |  |
| A1410 |  | UBICACIÓN Y DELIMITACIÓN DE LA ZONA DE PLANTACIÓN | 6.5d | 2023-03-01 | 2023-03-07 |  | 6d | 0d |  |
| A01420 |  | MEJORAMIENTO DE SUELO CON TIERRA VEGETAL | 220d | 2023-03-04 | 2023-10-09 | A1410 SS+3d | 6d | 0d |  |
| A1430 |  | DESPEDREGADO DEL TERRENO CON MEDIOS MANUALES | 220d | 2023-03-07 | 2023-10-12 | A01420 SS+3d | 6d | 0d |  |
| A1440 |  | RASTRILLADO DEL TERRENO | 220d | 2023-03-10 | 2023-10-15 | A1430 SS+3d | 6d | 0d |  |
| A1460 |  | RETIRO Y ELIMINACIÓN DE RESIDUOS SÓLIDOS | 220d | 2023-03-10 | 2023-10-15 | A1430 SS+3d | 107d | 101d |  |
| A1450 |  | TRAZADO, MARCACIÓN Y ESTACADO | 220d | 2023-03-11 | 2023-10-16 | A1440 SS+1d | 6d | 0d |  |

| ID | WBS | Activity | Duration | Start | Finish | Predecessors | Total float | Free float |
| --- | --- | --- | --- | --- | --- | --- | --- | --- |
|  | 2 | **ADQUISICION DE PLANTONES (altura al adquirirse)** |  | 2023-05-01 | 2023-10-17 |  |  |  |
| A1560 |  | BATIS MARITIMA VIDRIO (H:0.15m) | 85d | 2023-05-01 | 2023-07-24 | A1450 SS+51d | 6d | 0d |
| A1570 |  | ENCELIA CANESCEN GIRASOL SILVESTRE (0.20m a 0.30m) | 85d | 2023-05-01 | 2023-07-24 | A1560 SS | 6d | 0d |
| A1580 |  | PHYLA NODIFLORA LIPPIA (h:0.15m) | 85d | 2023-05-01 | 2023-07-24 | A1570 SS | 6d | 0d |
| A1590 |  | SESUVIUM PORTULACASTRUM PORTULACA (h:0.15m) | 85d | 2023-05-01 | 2023-07-24 | A1580 SS | 6d | 0d |
| A1600 |  | SCIRPUS CALIFORNICUS ENEA (h:0.50m) | 85d | 2023-05-01 | 2023-07-24 | A1590 SS | 6d | 0d |
| A1610 |  | SCIRPUS CONGLOMERATUS JUNCO (h:0.50m) | 85d | 2023-05-01 | 2023-07-24 | A1600 SS | 6d | 0d |
| A1620 |  | PASPALUM VAGINATUM GRAMA DE AGUA (h:0.15m) | 85d | 2023-05-01 | 2023-07-24 | A1610 SS | 6d | 0d |
| A1470 |  | PROSOPIS PALLIDA KUNTH ALGARROBO (0.80 a 1.50m) | 85d | 2023-07-25 | 2023-10-17 | A1620 | 6d | 0d |
| A1480 |  | SCHINUS MOLLE MOLLE SERRANO (0.80 a 1.50m) | 85d | 2023-07-25 | 2023-10-17 | A1470 SS | 6d | 0d |
| A1490 |  | ACACIA MACRACANTHA FAIQUE (0.80 a 1.50m) | 85d | 2023-07-25 | 2023-10-17 | A1480 SS | 6d | 0d |
| A1500 |  | PARKINSONIA ACULEATA AZOTE DE CRISTO (1.00 a 1.50 m) | 85d | 2023-07-25 | 2023-10-17 | A1490 SS | 6d | 0d |
| A1510 |  | TESSARIA INTEGRIFOLIA RUIZ & PAV PAJARRO BOBO (0.80 a 1.50m) | 85d | 2023-07-25 | 2023-10-17 | A1500 SS | 6d | 0d |
| A1550 |  | BACCHARIS SALICIFOLIA CHILCA (h:080 a 1.50m) | 85d | 2023-07-25 | 2023-10-17 | A1510 SS | 6d | 0d |
|  | 3 | **ADQUISICION RECALCE (Se concidera el 5%)** |  | 2023-07-25 | 2023-10-22 |  |  |  |
| A1690 |  | BATIS MARITIMA VIDRIO (H:0.15m) | 5d | 2023-07-25 | 2023-07-29 | A1560 | 185d | 179d |
| A1700 |  | ENCELIA CANESCEN GIRASOL SILVESTRE (0.20m a 0.30m) | 5d | 2023-07-25 | 2023-07-29 | A1570 | 185d | 179d |
| A1710 |  | PHYLA NODIFLORA LIPPIA (h:0.15m) | 5d | 2023-07-25 | 2023-07-29 | A1580 | 185d | 179d |
| A1720 |  | SESUVIUM PORTULACASTRUM PORTULACA (h:0.15m) | 5d | 2023-07-25 | 2023-07-29 | A1590 | 185d | 179d |
| A1730 |  | SCIRPUS CALIFORNICUS ENEA (h:0.50m) | 5d | 2023-07-25 | 2023-07-29 | A1600 | 185d | 179d |
| A1740 |  | SCIRPUS CONGLOMERATUS JUNCO (h:0.50m) | 5d | 2023-07-25 | 2023-07-29 | A1610 | 185d | 179d |
| A1750 |  | PASPALUM VAGINATUM GRAMA DE AGUA (h:0.15m) | 5d | 2023-07-25 | 2023-07-29 | A1620 | 185d | 179d |
| A1630 |  | PROSOPIS PALLIDA KUNTH ALGARROBO (0.80 a 1.50m) | 5d | 2023-10-18 | 2023-10-22 | A1470 | 100d | 94d |
| A1640 |  | SCHINUS MOLLE MOLLE SERRANO (0.80 a 1.50m) | 5d | 2023-10-18 | 2023-10-22 | A1480 | 100d | 94d |
| A1650 |  | ACACIA MACRACANTHA FAIQUE (0.80 a 1.50m) | 5d | 2023-10-18 | 2023-10-22 | A1490 | 100d | 94d |
| A1660 |  | PARKINSONIA ACULEATA AZOTE DE CRISTO (1.00 a 1.50 m) | 5d | 2023-10-18 | 2023-10-22 | A1500 | 100d | 94d |
| A1670 |  | TESSARIA INTEGRIFOLIA RUIZ & PAV PAJARRO BOBO (0.80 a 1.50m) | 5d | 2023-10-18 | 2023-10-22 | A1510 | 100d | 94d |
| A1680 |  | BACCHARIS SALICIFOLIA CHILCA (h:080 a 1.50m) | 5d | 2023-10-18 | 2023-10-22 | A1550 | 100d | 94d |

| ID | WBS | Activity | Duration | Start | Finish | Predecessors | Total float | Free float |
| --- | --- | --- | --- | --- | --- | --- | --- | --- |
|  | 4 | **TRANSPORTE** |  | 2023-05-01 | 2023-10-22 |  |  |  |
| A1760 |  | Flete transporte terrestre para especies vegetales | 175d | 2023-05-01 | 2023-10-22 | A1560 SS | 100d | 94d |
|  | 5 | **ADQUISICION INSUMOS AGRICOLAS Y OTROS** |  | 2023-05-01 | 2023-10-22 |  |  |  |
| A1770 |  | COMPOST SACO 35kg | 175d | 2023-05-01 | 2023-10-22 | A1560 SS | 100d | 0d |
| A1780 |  | AZUFRE SACO 25kg | 175d | 2023-05-01 | 2023-10-22 | A1770 SS | 100d | 0d |
| A1790 |  | YESO SACO 40kg | 175d | 2023-05-01 | 2023-10-22 | A1780 SS | 100d | 0d |
| A1800 |  | NPK 10:30:10 SACO DE 50kg | 175d | 2023-05-01 | 2023-10-22 | A1790 SS | 100d | 0d |
| A1810 |  | NPK 20:20:20 SACO DE 50kg | 175d | 2023-05-01 | 2023-10-22 | A1800 SS | 100d | 0d |
| A1820 |  | TUTORES EUCALIPTO 2.5m | 175d | 2023-05-01 | 2023-10-22 | A1810 SS | 100d | 0d |
| A1830 |  | SOGA DE YUTE 5/64 DE 58m | 175d | 2023-05-01 | 2023-10-22 | A1820 SS | 100d | 0d |
| A1840 |  | PITON CONTRA INCENDIO PARA ADAPTACION DE MANGUERA DE CISTERNA | 3d | 2023-05-01 | 2023-05-03 | A1830 SS | 272d | 266d |
|  | 6 | **INSTALACION DE PLANTONES (Incluye colocacion de sustrato, tierra del lugar,** |  | 2023-05-01 | 2023-10-26 |  |  |  |
| A1910 |  | BATIS MARITIMA VIDRIO (H:0.15m) | 90d | 2023-05-01 | 2023-07-29 | A1560 SS | 185d | 179d |
| A1920 |  | ENCELIA CANESCEN GIRASOL SILVESTRE (0.20m a 0.30m) | 90d | 2023-05-01 | 2023-07-29 | A1570 SS | 185d | 179d |
| A1930 |  | PHYLA NODIFLORA LIPPIA (h:0.15m) | 90d | 2023-05-01 | 2023-07-29 | A1580 SS | 185d | 179d |
| A1940 |  | SESUVIUM PORTULACASTRUM PORTULACA (h:0.15m) | 90d | 2023-05-01 | 2023-07-29 | A1590 SS | 185d | 179d |
| A1950 |  | SCIRPUS CALIFORNICUS ENEA (h:0.50m) | 90d | 2023-05-01 | 2023-07-29 | A1600 SS | 185d | 179d |
| A1960 |  | SCIRPUS CONGLOMERATUS JUNCO (h:0.50m) | 90d | 2023-05-01 | 2023-07-29 | A1610 SS | 185d | 179d |
| A1970 |  | PASPALUM VAGINATUM GRAMA DE AGUA (h:0.15m) | 90d | 2023-05-01 | 2023-07-29 | A1620 SS | 185d | 179d |
| A1850 |  | PROSOPIS PALLIDA KUNTH ALGARROBO (0.80 a 1.50m) | 90d | 2023-07-29 | 2023-10-26 | A1470 SS+4d | 96d | 0d |
| A1860 |  | SCHINUS MOLLE MOLLE SERRANO (0.80 a 1.50m) | 90d | 2023-07-29 | 2023-10-26 | A1480 SS+4d | 96d | 90d |
| A1870 |  | ACACIA MACRACANTHA FAIQUE (0.80 a 1.50m) | 90d | 2023-07-29 | 2023-10-26 | A1490 SS+4d | 96d | 90d |
| A1880 |  | PARKINSONIA ACULEATA AZOTE DE CRISTO (1.00 a 1.50 m) | 90d | 2023-07-29 | 2023-10-26 | A1500 SS+4d | 96d | 90d |
| A1890 |  | TESSARIA INTEGRIFOLIA RUIZ & PAV PAJARRO BOBO (0.80 a 1.50m) | 90d | 2023-07-29 | 2023-10-26 | A1510 SS+4d | 96d | 90d |
| A1900 |  | BACCHARIS SALICIFOLIA CHILCA (h:080 a 1.50m) | 90d | 2023-07-29 | 2023-10-26 | A1550 SS+4d | 6d | 0d |

| ID | WBS | Activity | Duration | Start | Finish | Predecessors | Total float | Free float |
| --- | --- | --- | --- | --- | --- | --- | --- | --- |
|  | 7 | **INSTALACIÓN DE ALCORQUES** |  | 2023-07-29 | 2023-10-26 |  |  |  |
| A1980 |  | ALCORQUES DE PIEDRA DE CANTO RODADO PARA ARBOLES | 89.25d | 2023-07-29 | 2023-10-26 | A1850 SS | 96.75d | 90.75d |
|  | 8 | **RIEGO DE ESPECIES 12 MESES ( instalacion+establecimiento)** |  | 2023-10-27 | 2024-01-24 |  |  |  |
| A1990 |  | Riego por inundación, mediante camión cisterna con mangera adaptada con piton | 90d | 2023-10-27 | 2024-01-24 | A1900 | 6d | 0d |
|  | 9 | **MANTENIMIENTO PREVENTIVO PARA ESTABLECIMIENTO DE ESPECIE (12** |  | 2023-10-27 | 2024-01-24 |  |  |  |
| A2000 |  | MANO DE OBRA + PODA + REMOCION, DESMALEZADO, RECALCE Y | 90d | 2023-10-27 | 2024-01-24 | A1990 SS | 6d | 0d |
|  | 6 | **SUBPROYECTO A3 - PUENTE CHACHAPOYAS** |  | 2023-08-03 | 2024-01-13 |  |  |  |
|  | 1 | **OBRAS PRELIMINARES** |  | 2023-08-03 | 2023-10-13 |  |  |  |
| A3520 |  | UBICACIÓN Y DELIMITACIÓN DE LA ZONA DE PLANTACIÓN | 2d | 2023-08-03 | 2023-08-05 | A4320 | 17.5d | 0d |
| A3510 |  | MEJORAMIENTO DE SUELO CON TIERRA VEGETAL | 68d | 2023-08-04 | 2023-10-11 | A3520 SS+1d | 17.5d | 0d |
| A3530 |  | DESPEDREGADO DEL TERRENO CON MEDIOS MANUALES | 68d | 2023-08-05 | 2023-10-12 | A3510 SS+1d | 17.5d | 0d |
| A3540 |  | RASTRILLADO DEL TERRENO | 68d | 2023-08-06 | 2023-10-13 | A3530 SS+1d | 17.5d | 0d |
| A3550 |  | TRAZADO, MARCACIÓN Y ESTACADO | 68d | 2023-08-06 | 2023-10-13 | A3540 SS | 17.5d | 0d |
| A3560 |  | RETIRO Y ELIMINACIÓN DE RESIDUOS SÓLIDOS | 68d | 2023-08-06 | 2023-10-13 | A3530 SS+1d | 109.5d | 103.5d |
|  | 2 | **ADQUISICION DE PLANTONES (altura al adquirirse)** |  | 2023-08-21 | 2023-10-12 |  |  |  |
| A3620 |  | SENNA MULTIGLANDULOSA MUTUY (0.60 a 0.80m) | 26d | 2023-08-21 | 2023-09-16 | A3550 SS+15d | 17.5d | 0d |
| A3630 |  | ENCELIA CANESCEN GIRASOL SILVESTRE (0.20m a 0.30m) | 26d | 2023-08-21 | 2023-09-16 | A3620 SS | 17.5d | 0d |
| A3640 |  | WEDELIA TRIBOLATA WEDELIA (0.15m) | 26d | 2023-08-21 | 2023-09-16 | A3630 SS | 17.5d | 0d |
| A3570 |  | PROSOPIS PALLIDA KUNTH ALGARROBO (0.80 a 1.50m) | 26d | 2023-09-16 | 2023-10-12 | A3640 | 17.5d | 0d |
| A3580 |  | SCHINUS MOLLE MOLLE SERRANO (0.80 a 1.50m) | 26d | 2023-09-16 | 2023-10-12 | A3570 SS | 107.5d | 0d |
| A3590 |  | ACACIA MACRACANTHA FAIQUE (0.80 a 1.50m) | 26d | 2023-09-16 | 2023-10-12 | A3580 SS | 107.5d | 0d |
| A3600 |  | PARKINSONIA ACULEATA AZOTE DE CRISTO (1.00 a 1.50 m) | 26d | 2023-09-16 | 2023-10-12 | A3590 SS | 107.5d | 0d |
| A3610 |  | TESSARIA INTEGRIFOLIA RUIZ & PAV PAJARRO BOBO (0.80 a 1.50m) | 26d | 2023-09-16 | 2023-10-12 | A3600 SS | 107.5d | 0d |
|  | 3 | **ADQUISICION RECALCE (Se concidera el 5%)** |  | 2023-09-16 | 2023-10-13 |  |  |  |
| A3700 |  | SENNA MULTIGLANDULOSA MUTUY (0.60 a 0.80m) | 1d | 2023-09-16 | 2023-09-17 | A3620 | 135.5d | 0d |
| A3710 |  | ENCELIA CANESCEN GIRASOL SILVESTRE (0.20m a 0.30m) | 1d | 2023-09-16 | 2023-09-17 | A3700 SS | 135.5d | 0d |
| A3720 |  | WEDELIA TRIBOLATA WEDELIA (0.15m) | 1d | 2023-09-16 | 2023-09-17 | A3710 SS | 135.5d | 129.5d |
| A3650 |  | PROSOPIS PALLIDA KUNTH ALGARROBO (0.80 a 1.50m) | 1d | 2023-10-12 | 2023-10-13 | A3570 | 109.5d | 0d |
| A3660 |  | SCHINUS MOLLE MOLLE SERRANO (0.80 a 1.50m) | 1d | 2023-10-12 | 2023-10-13 | A3650 SS | 109.5d | 0d |
| A3670 |  | ACACIA MACRACANTHA FAIQUE (0.80 a 1.50m) | 1d | 2023-10-12 | 2023-10-13 | A3660 SS | 109.5d | 0d |
| A3680 |  | PARKINSONIA ACULEATA AZOTE DE CRISTO (1.00 a 1.50 m) | 1d | 2023-10-12 | 2023-10-13 | A3670 SS | 109.5d | 0d |
| A3690 |  | TESSARIA INTEGRIFOLIA RUIZ & PAV PAJARRO BOBO (0.80 a 1.50m) | 1d | 2023-10-12 | 2023-10-13 | A3680 SS | 109.5d | 103.5d |

| ID | WBS | Activity | Duration | Start | Finish | Predecessors | Total float | Free float |
| --- | --- | --- | --- | --- | --- | --- | --- | --- |
|  | 4 | **TRANSPORTE** |  | 2023-08-21 | 2023-10-13 |  |  |  |
| A3730 |  | Flete transporte terrestre para especies vegetales | 53d | 2023-08-21 | 2023-10-13 | A3620 SS | 109.5d | 103.5d |
|  | 5 | **ADQUISICION INSUMOS AGRICOLAS Y OTROS** |  | 2023-08-21 | 2023-10-13 |  |  |  |
| A3740 |  | COMPOST SACO 35kg | 53d | 2023-08-21 | 2023-10-13 | A3620 SS | 109.5d | 0d |
| A3750 |  | AZUFRE SACO 25kg | 53d | 2023-08-21 | 2023-10-13 | A3740 SS | 109.5d | 0d |
| A3760 |  | YESO SACO 40kg | 53d | 2023-08-21 | 2023-10-13 | A3750 SS | 109.5d | 0d |
| A3770 |  | NPK 10:30:10 SACO DE 50kg | 53d | 2023-08-21 | 2023-10-13 | A3760 SS | 109.5d | 0d |
| A3780 |  | NPK 20:20:20 SACO DE 50kg | 53d | 2023-08-21 | 2023-10-13 | A3770 SS | 109.5d | 0d |
| A3790 |  | TUTORES EUCALIPTO 2.5m | 53d | 2023-08-21 | 2023-10-13 | A3780 SS | 109.5d | 0d |
| A3800 |  | SOGA DE YUTE 5/64 DE 58m | 53d | 2023-08-21 | 2023-10-13 | A3790 SS | 109.5d | 0d |
| A3810 |  | PITON CONTRA INCENDIO PARA ADAPTACION DE MANGUERA DE CISTERNA | 3d | 2023-08-21 | 2023-08-24 | A3800 SS | 159.5d | 153.5d |
|  | 6 | **INSTALACION DE PLANTONES (Incluye colocacion de sustrato, tierra del lugar,** |  | 2023-08-22 | 2023-10-15 |  |  |  |
| A3870 |  | SENNA MULTIGLANDULOSA MUTUY (0.60 a 0.80m) | 28d | 2023-08-22 | 2023-09-19 | A3620 SS+1d | 133.5d | 127.5d |
| A3880 |  | ENCELIA CANESCEN GIRASOL SILVESTRE (0.20m a 0.30m) | 28d | 2023-08-22 | 2023-09-19 | A3630 SS+1d | 133.5d | 127.5d |
| A3890 |  | WEDELIA TRIBOLATA WEDELIA (0.15m) | 28d | 2023-08-22 | 2023-09-19 | A3640 SS+1d | 133.5d | 127.5d |
| A3820 |  | PROSOPIS PALLIDA KUNTH ALGARROBO (0.80 a 1.50m) | 28d | 2023-09-17 | 2023-10-15 | A3570 SS+1d | 17.5d | 0d |
| A3830 |  | SCHINUS MOLLE MOLLE SERRANO (0.80 a 1.50m) | 28d | 2023-09-17 | 2023-10-15 | A3580 SS+1d | 107.5d | 101.5d |
| A3840 |  | ACACIA MACRACANTHA FAIQUE (0.80 a 1.50m) | 28d | 2023-09-17 | 2023-10-15 | A3590 SS+1d | 107.5d | 101.5d |
| A3850 |  | PARKINSONIA ACULEATA AZOTE DE CRISTO (1.00 a 1.50 m) | 28d | 2023-09-17 | 2023-10-15 | A3600 SS+1d | 107.5d | 101.5d |
| A3860 |  | TESSARIA INTEGRIFOLIA RUIZ & PAV PAJARRO BOBO (0.80 a 1.50m) | 28d | 2023-09-17 | 2023-10-15 | A3610 SS+1d | 107.5d | 101.5d |
|  | 7 | **NSTALACIÓN DE ALCORQUES** |  | 2023-09-17 | 2023-10-14 |  |  |  |
| A3900 |  | ALCORQUES DE PIEDRA DE CANTO RODADO PARA ARBOLES | 27.25d | 2023-09-17 | 2023-10-14 | A3820 SS | 108.25d | 102.25d |
|  | 8 | **RIEGO DE ESPECIES 12 MESES ( instalacion+establecimiento)** |  | 2023-10-15 | 2024-01-13 |  |  |  |
| A3910 |  | Riego por inundación, mediante camión cisterna con mangera adaptada con piton | 90d | 2023-10-15 | 2024-01-13 | A3820 | 17.5d | 0d |

| ID | WBS | Activity | Type | Duration | Start | Finish | Predecessors | Total float | Free float |
| --- | --- | --- | --- | --- | --- | --- | --- | --- | --- |
|  | 9 | **MANTENIMIENTO PREVENTIVO PARA ESTABLECIMIENTO DE ESPECIE (12** |  |  | 2023-10-15 | 2024-01-13 |  |  |  |
| A3920 |  | MANO DE OBRA + PODA + REMOCION, DESMALEZADO, RECALCE Y |  | 90d | 2023-10-15 | 2024-01-13 | A3910 SS | 17.5d | 11.5d |
|  | 7 | **FIN)** |  |  | 2024-01-24 | 2024-01-24 |  |  |  |
| A4360 |  | FIN | milestone | 0d | 2024-01-24 | 2024-01-24 | A2000 FF | 6d | 0d |
